# Phase4

Schedule from MS Project, 2013-11-26 to 2014-05-22, costs in $.

## Calendars

- Standard: Mon-Fri 08:00-12:00, 13:00-17:00; Sat-Sun off.

## Resources

| Resource | Rate |
| --- | --- |
| A | 105 |
| B | 105 |
| C | 105 |
| D | 105 |
| E | 105 |
| F | 105 |
| G | 105 |
| H | 105 |
| I | 105 |
| J | 105 |
| K | 105 |
| DDT | 630 |
| Sales | 210 |
| Research | 315 |
| QA | 420 |

## Schedule

| ID | WBS | Task | Duration | Start | Finish | Predecessors | Total slack | Resources | Work | Cost |
| --- | --- | --- | --- | --- | --- | --- | --- | --- | --- | --- |
| 1 | 1 | **Project** | 128d | 2013-11-26 | 2014-05-22 |  | 0d |  | 3536h | 1,097,880 |
| 2 | 1.1 | **Development** | 110d | 2013-11-26 | 2014-04-28 |  | 0d |  | 3328h | 980,280 |
| 3 | 1.1.1 | **App Development** | 110d | 2013-11-26 | 2014-04-28 |  | 0d |  | 1712h | 810,600 |
| 4 | 1.1.1.1 | **Define Problem** | 17d | 2013-11-26 | 2013-12-18 |  | 0d |  | 312h | 126,840 |
| 5 | 1.1.1.1.1 | **Identify Problem** | 3d | 2013-11-26 | 2013-11-28 |  | 0d | DDT; Sales | 48h | 20,160 |
| 6 | 1.1.1.1.1.1 | Narrate problem to be solved | 1d | 2013-11-26 | 2013-11-26 |  | 0d |  |  |  |
| 7 | 1.1.1.1.1.2 | Detail a list of requirements | 1d | 2013-11-27 | 2013-11-27 | 6 | 0d |  |  |  |
| 8 | 1.1.1.1.1.3 | Identify who will be using the system | 1d | 2013-11-28 | 2013-11-28 | 7 | 0d |  |  |  |
| 9 | 1.1.1.1.2 | **Research** | 5d | 2013-11-29 | 2013-12-05 | 5 | 0d | DDT; Research; Sales | 120h | 46,200 |
| 10 | 1.1.1.1.2.1 | Research Existing Solutions | 1d | 2013-11-29 | 2013-11-29 |  | 0d |  |  |  |
| 11 | 1.1.1.1.2.2 | List pros and cons of each existing solution | 1d | 2013-12-02 | 2013-12-02 | 10 | 0d |  |  |  |
| 12 | 1.1.1.1.2.3 | Analyze existing technology for this problem | 3d | 2013-12-03 | 2013-12-05 | 11 | 0d |  |  |  |
| 13 | 1.1.1.1.3 | **Identify Possible Solutions** | 9d | 2013-12-06 | 2013-12-18 | 9 | 0d | DDT; Sales | 144h | 60,480 |
| 14 | 1.1.1.1.3.1 | Suggest original or improved solutions to problem | 1d | 2013-12-06 | 2013-12-06 |  | 0d |  |  |  |
| 15 | 1.1.1.1.3.2 | Detail out what system will do for each solution | 2d | 2013-12-09 | 2013-12-10 | 14 | 0d |  |  |  |
| 16 | 1.1.1.1.3.3 | Analyze if new technology will be needed for each solution | 2d | 2013-12-11 | 2013-12-12 | 15 | 0d |  |  |  |
| 17 | 1.1.1.1.3.4 | Identify major technical obstacles that may arise for each solution | 1d | 2013-12-13 | 2013-12-13 | 16 | 0d |  |  |  |
| 18 | 1.1.1.1.3.5 | Discuss and identify equipment needed for each solution | 3d | 2013-12-16 | 2013-12-18 | 17 | 0d |  |  |  |
| 19 | 1.1.1.2 | **Determine Requirements** | 7d | 2013-12-19 | 2013-12-27 | 4 | 0d | DDT; Sales | 112h | 47,040 |
| 20 | 1.1.1.2.1 | **Customer Meeting** | 7d | 2013-12-19 | 2013-12-27 |  | 0d |  |  |  |
| 21 | 1.1.1.2.1.1 | Present solutions and research to customer | 1d | 2013-12-19 | 2013-12-19 |  | 0d |  |  |  |
| 22 | 1.1.1.2.1.2 | Obtain customer feedback | 4d | 2013-12-20 | 2013-12-25 | 21 | 0d |  |  |  |
| 23 | 1.1.1.2.1.3 | Decide on a solution path to take | 2d | 2013-12-26 | 2013-12-27 | 22 | 0d |  |  |  |
| 24 | 1.1.1.3 | **SRS Development** | 29d | 2013-12-30 | 2014-02-06 | 19 | 0d | DDT; Sales | 464h | 194,880 |
| 25 | 1.1.1.3.1 | **Discuss Possible Software Architecture** | 7d | 2013-12-30 | 2014-01-07 |  | 0d |  |  |  |
| 26 | 1.1.1.3.1.1 | Identify software requirements | 2d | 2013-12-30 | 2013-12-31 |  | 0d |  |  |  |
| 27 | 1.1.1.3.1.2 | Discuss possible software architectures | 3d | 2014-01-01 | 2014-01-03 | 26 | 0d |  |  |  |
| 28 | 1.1.1.3.1.3 | List pros and cons of each architecture | 2d | 2014-01-06 | 2014-01-07 | 27 | 0d |  |  |  |

| ID | WBS | Task | Duration | Start | Finish | Predecessors | Total slack | Resources | Work | Cost |
| --- | --- | --- | --- | --- | --- | --- | --- | --- | --- | --- |
| 29 | 1.1.1.3.2 | **Decide on software architecture** | 6d | 2014-01-08 | 2014-01-15 | 25 | 0d |  |  |  |
| 30 | 1.1.1.3.2.1 | Review architectures | 1d | 2014-01-08 | 2014-01-08 |  | 0d |  |  |  |
| 31 | 1.1.1.3.2.2 | Decide on architecture | 3d | 2014-01-09 | 2014-01-13 | 30 | 0d |  |  |  |
| 32 | 1.1.1.3.2.3 | Detail modules for this architecture | 2d | 2014-01-14 | 2014-01-15 | 31 | 0d |  |  |  |
| 33 | 1.1.1.3.3 | **GUI** | 5d | 2014-01-16 | 2014-01-22 | 29 | 0d |  |  |  |
| 34 | 1.1.1.3.3.1 | Develop sample user screens | 3d | 2014-01-16 | 2014-01-20 |  | 0d |  |  |  |
| 35 | 1.1.1.3.3.2 | Discuss usability testing | 2d | 2014-01-21 | 2014-01-22 | 34 | 0d |  |  |  |
| 36 | 1.1.1.3.4 | **Integration Thread** | 7d | 2014-01-23 | 2014-01-31 | 33 | 0d |  |  |  |
| 37 | 1.1.1.3.4.1 | Discuss possible changes to software requirements | 2d | 2014-01-23 | 2014-01-24 |  | 0d |  |  |  |
| 38 | 1.1.1.3.4.2 | Identify basic requirements for each module | 3d | 2014-01-27 | 2014-01-29 | 37 | 0d |  |  |  |
| 39 | 1.1.1.3.4.3 | Discuss extensibility of software system | 2d | 2014-01-30 | 2014-01-31 | 38 | 0d |  |  |  |
| 40 | 1.1.1.3.5 | **Cross-Reference Listing** | 4d | 2014-02-03 | 2014-02-06 | 36 | 0d |  |  |  |
| 41 | 1.1.1.3.5.1 | Design list of system requirements to ensure all tasks are completed | 4d | 2014-02-03 | 2014-02-06 |  | 0d |  |  |  |
| 42 | 1.1.1.4 | **Design and Implementation** | 22d | 2014-02-07 | 2014-03-10 | 24 | 0d | DDT | 176h | 110,880 |
| 43 | 1.1.1.4.1 | **Programming Languages and Platforms** | 5d | 2014-02-07 | 2014-02-13 |  | 0d |  |  |  |
| 44 | 1.1.1.4.1.1 | Discuss possible platforms and languages | 1d | 2014-02-07 | 2014-02-07 |  | 0d |  |  |  |
| 45 | 1.1.1.4.1.2 | Research existing languages and platforms | 2d | 2014-02-10 | 2014-02-11 | 44 | 0d |  |  |  |
| 46 | 1.1.1.4.1.3 | Decide on language and platform | 2d | 2014-02-12 | 2014-02-13 | 45 | 0d |  |  |  |
| 47 | 1.1.1.4.2 | **High Level Implementation Description** | 3d | 2014-02-14 | 2014-02-18 | 43 | 0d |  |  |  |
| 48 | 1.1.1.4.2.1 | Design high-level software implementation of each module | 3d | 2014-02-14 | 2014-02-18 |  | 0d |  |  |  |
| 49 | 1.1.1.4.3 | **Implementation** | 14d | 2014-02-19 | 2014-03-10 | 47 | 0d |  |  |  |
| 50 | 1.1.1.4.3.1 | Code individual modules | 14d | 2014-02-19 | 2014-03-10 |  | 0d |  |  |  |
| 51 | 1.1.1.5 | **Automated Testing** | 35d | 2014-03-11 | 2014-04-28 | 42 | 0d | DDT | 280h | 176,400 |
| 52 | 1.1.1.5.1 | **Identify Functionalities to be Tested** | 2d | 2014-03-11 | 2014-03-12 |  | 0d |  |  |  |
| 53 | 1.1.1.5.1.1 | Test individual modules | 1d | 2014-03-11 | 2014-03-11 |  | 0d |  |  |  |
| 54 | 1.1.1.5.1.2 | Test complete architecture | 1d | 2014-03-12 | 2014-03-12 | 53 | 0d |  |  |  |

| ID | WBS | Task | Duration | Start | Finish | Predecessors | Total slack |
| --- | --- | --- | --- | --- | --- | --- | --- |
| 55 | 1.1.1.5.2 | **First Round of Testing** | 4d | 2014-03-13 | 2014-03-18 | 52 | 0d |
| 56 | 1.1.1.5.2.1 | Implement test cases | 2d | 2014-03-13 | 2014-03-14 |  | 0d |
| 57 | 1.1.1.5.2.2 | Perform tests and document results | 2d | 2014-03-17 | 2014-03-18 | 56 | 0d |
| 58 | 1.1.1.5.3 | **First Error Correction** | 7d | 2014-03-19 | 2014-03-27 | 55 | 0d |
| 59 | 1.1.1.5.3.1 | Develop and discuss possible solutions to failed test cases | 1d | 2014-03-19 | 2014-03-19 |  | 0d |
| 60 | 1.1.1.5.3.2 | Identify necessary changes to software | 1d | 2014-03-20 | 2014-03-20 | 59 | 0d |
| 61 | 1.1.1.5.3.3 | Assign changes to appropriate modules | 1d | 2014-03-21 | 2014-03-21 | 60 | 0d |
| 62 | 1.1.1.5.3.4 | Implement fixes | 4d | 2014-03-24 | 2014-03-27 | 61 | 0d |
| 63 | 1.1.1.5.4 | **Second Error Correction** | 7d | 2014-03-28 | 2014-04-07 | 58 | 0d |
| 64 | 1.1.1.5.4.1 | Develop and discuss possible solutions to failed test cases | 1d | 2014-03-28 | 2014-03-28 |  | 0d |
| 65 | 1.1.1.5.4.2 | Identify necessary changes to software | 1d | 2014-03-31 | 2014-03-31 | 64 | 0d |
| 66 | 1.1.1.5.4.3 | Assign changes to appropriate modules | 1d | 2014-04-01 | 2014-04-01 | 65 | 0d |
| 67 | 1.1.1.5.4.4 | Implement fixes | 4d | 2014-04-02 | 2014-04-07 | 66 | 0d |
| 68 | 1.1.1.5.5 | **Second Round of Testing** | 4d | 2014-04-08 | 2014-04-11 | 63 | 0d |
| 69 | 1.1.1.5.5.1 | Implement test cases | 2d | 2014-04-08 | 2014-04-09 |  | 0d |
| 70 | 1.1.1.5.5.2 | Perform tests and document results | 2d | 2014-04-10 | 2014-04-11 | 69 | 0d |
| 71 | 1.1.1.5.6 | **Third Error Correction** | 7d | 2014-04-14 | 2014-04-22 | 68 | 0d |
| 72 | 1.1.1.5.6.1 | Develop and discuss possible solutions to failed test cases | 1d | 2014-04-14 | 2014-04-14 |  | 0d |
| 73 | 1.1.1.5.6.2 | Identify necessary changes to software | 1d | 2014-04-15 | 2014-04-15 | 72 | 0d |
| 74 | 1.1.1.5.6.3 | Assign changes to appropriate modules | 1d | 2014-04-16 | 2014-04-16 | 73 | 0d |
| 75 | 1.1.1.5.6.4 | Implement fixes | 4d | 2014-04-17 | 2014-04-22 | 74 | 0d |
| 76 | 1.1.1.5.7 | **Third Round of Testing** | 4d | 2014-04-23 | 2014-04-28 | 71 | 0d |
| 77 | 1.1.1.5.7.1 | Implement test cases | 2d | 2014-04-23 | 2014-04-24 |  | 0d |
| 78 | 1.1.1.5.7.2 | Perform tests and document results | 2d | 2014-04-25 | 2014-04-28 | 77 | 0d |

| ID | WBS | Task | Duration | Start | Finish | Predecessors | Total slack | Free slack | Constraint | Resources | Work | Cost |
| --- | --- | --- | --- | --- | --- | --- | --- | --- | --- | --- | --- | --- |
| 79 | 1.1.1.6 | **Usability Testing** | 18d | 2013-11-26 | 2013-12-19 |  | 92d |  |  | DDT; Sales | 368h | 154,560 |
| 80 | 1.1.1.6.1 | **Screen Users** | 5d | 2013-11-26 | 2013-12-02 |  | 92d | 0d |  | QA | 40h | 16,800 |
| 81 | 1.1.1.6.1.1 | Find users with varying levels of computer literacy and familiarity with asthma | 5d | 2013-11-26 | 2013-12-02 |  | 92d |  |  |  |  |  |
| 82 | 1.1.1.6.2 | **Create Task List** | 1d | 2013-12-03 | 2013-12-03 | 80 | 92d | 0d |  |  |  |  |
| 83 | 1.1.1.6.2.1 | Create a list of a basic tasks required to operate the app | 1d | 2013-12-03 | 2013-12-03 |  | 92d |  |  |  |  |  |
| 84 | 1.1.1.6.3 | **Observe Users** | 5d | 2013-12-04 | 2013-12-10 | 82 | 92d | 0d |  | QA | 40h | 16,800 |
| 85 | 1.1.1.6.3.1 | Create User Feedback Form | 1d | 2013-12-04 | 2013-12-04 |  | 92d | 0d |  |  |  |  |
| 86 | 1.1.1.6.3.2 | Document how users interacts with phone app | 1d | 2013-12-05 | 2013-12-05 | 85 | 92d | 0d |  |  |  |  |
| 87 | 1.1.1.6.3.3 | Document which tasks confused users | 2d | 2013-12-06 | 2013-12-09 | 86 | 92d | 0d |  |  |  |  |
| 88 | 1.1.1.6.3.4 | Evaluate user feedback forms | 1d | 2013-12-10 | 2013-12-10 | 87 | 92d |  |  |  |  |  |
| 89 | 1.1.1.6.4 | **Analyze Documentation** | 2d | 2013-12-11 | 2013-12-12 | 84 | 92d | 0d |  |  |  |  |
| 90 | 1.1.1.6.4.1 | Identify necessary changes to GUI | 2d | 2013-12-11 | 2013-12-12 |  | 92d |  |  |  |  |  |
| 91 | 1.1.1.6.5 | Implement Design Changes | 5d | 2013-12-13 | 2013-12-19 | 89 | 92d |  |  |  |  |  |
| 92 | 1.1.2 | **Sensor Development** | 65d | 2014-01-01 | 2014-04-01 |  | 19d |  |  |  | 1616h | 169,680 |
| 93 | 1.1.2.1 | **Requirement Gathering** | 11d | 2014-01-01 | 2014-01-15 |  | 73d |  |  |  | 88h | 9,240 |
| 94 | 1.1.2.1.1 | **First Meeting With Customer** | 2d | 2014-01-01 | 2014-01-02 |  | 73d | 0d |  |  | 16h | 1,680 |
| 95 | 1.1.2.1.1.1 | problem Discussion | 2d | 2014-01-01 | 2014-01-02 |  | 73d |  | start no earlier than 2014-01-01 | A | 16h | 1,680 |
| 96 | 1.1.2.1.2 | **Team Meeting** | 2d | 2014-01-03 | 2014-01-06 |  | 73d | 0d |  |  | 16h | 1,680 |
| 97 | 1.1.2.1.2.1 | Analysis of problem | 2d | 2014-01-03 | 2014-01-06 | 94 | 73d |  | start no earlier than 2014-01-02 | A | 16h | 1,680 |
| 98 | 1.1.2.1.3 | **Customer Meeting** | 7d | 2014-01-07 | 2014-01-15 |  | 73d |  |  |  | 56h | 5,880 |
| 99 | 1.1.2.1.3.1 | Evaluation of possible solution | 3d | 2014-01-07 | 2014-01-09 | 96 | 73d | 0d |  | B | 24h | 2,520 |
| 100 | 1.1.2.1.3.2 | Proposed Solutions | 2d | 2014-01-10 | 2014-01-13 | 99 | 73d | 0d |  | C | 16h | 1,680 |
| 101 | 1.1.2.1.3.3 | Feasibility of Propsed Solution | 2d | 2014-01-14 | 2014-01-15 | 100 | 73d |  |  | D | 16h | 1,680 |
| 102 | 1.1.2.2 | **SRS Preparation** | 12d | 2014-01-09 | 2014-01-24 |  | 33d |  |  |  | 264h | 27,720 |
| 103 | 1.1.2.2.1 | **Team Meeting** | 5d | 2014-01-09 | 2014-01-15 |  | 36d | 0d |  |  | 48h | 5,040 |
| 104 | 1.1.2.2.1.1 | Identification of Different Components | 3d | 2014-01-09 | 2014-01-13 |  | 36d | 0d | start no earlier than 2014-01-09 | A | 24h | 2,520 |
| 105 | 1.1.2.2.1.2 | Discussion and analysis of Sensor, Mini Storage, Alert, Configuration, Interaction | 2d | 2014-01-14 | 2014-01-15 | 104 | 36d |  |  | B | 16h | 1,680 |
| 106 | 1.1.2.2.1.3 | Assign individual module | 1d | 2014-01-15 | 2014-01-15 |  | 36d |  | start no earlier than 2014-01-15 | A | 8h | 840 |
| 107 | 1.1.2.2.2 | SRS Preparation for Sensor module | 4d | 2014-01-16 | 2014-01-21 | 103 | 36d | 0d |  | A | 32h | 3,360 |
| 108 | 1.1.2.2.3 | SRS Preparation for Mini Storage module | 4d | 2014-01-16 | 2014-01-21 | 103 | 36d | 0d |  | B | 32h | 3,360 |
| 109 | 1.1.2.2.4 | SRS Preparation for Alert module | 4d | 2014-01-16 | 2014-01-21 | 103 | 36d | 0d |  | C | 32h | 3,360 |
| 110 | 1.1.2.2.5 | SRS Preparation for Configuration module | 2d | 2014-01-16 | 2014-01-17 | 103 | 38d | 2d |  | D | 16h | 1,680 |
| 111 | 1.1.2.2.6 | SRS Preparation for Interaction module | 4d | 2014-01-16 | 2014-01-21 | 103 | 36d | 0d |  | E | 32h | 3,360 |
| 112 | 1.1.2.2.7 | Evaluation of HW modules for Procurement | 2d | 2014-01-22 | 2014-01-23 | 107, 108, 109, 110, 111 | 36d | 0d | start no earlier than 2013-11-27 | B | 16h | 1,680 |

| ID | WBS | Task | Duration | Start | Finish | Predecessors | Total slack | Free slack | Constraint | Resources | Work | Cost |
| --- | --- | --- | --- | --- | --- | --- | --- | --- | --- | --- | --- | --- |
| 113 | 1.1.2.2.8 | **Team Meeting** | 2d | 2014-01-22 | 2014-01-23 |  | 66d |  |  |  | 16h | 1,680 |
| 114 | 1.1.2.2.8.1 | Integration of modules | 1d | 2014-01-22 | 2014-01-22 | 107, 108, 109, 110, 111 | 66d | 0d |  | A | 8h | 840 |
| 115 | 1.1.2.2.8.2 | Review SRS and send version 1.0 to customer | 1d | 2014-01-23 | 2014-01-23 | 114 | 66d | 0d |  | A | 8h | 840 |
| 116 | 1.1.2.2.9 | **Team meeting** | 4d | 2014-01-21 | 2014-01-24 |  | 25d |  |  |  | 16h | 1,680 |
| 117 | 1.1.2.2.9.1 | Discuss comments by customer on SRS | 1d | 2014-01-24 | 2014-01-24 | 115 | 66d |  |  | A | 8h | 840 |
| 118 | 1.1.2.2.9.2 | Rework assignment of each module | 1d | 2014-01-21 | 2014-01-21 |  | 25d | 0d | start no earlier than 2014-01-21 | D | 8h | 840 |
| 119 | 1.1.2.2.10 | Rework | 2d | 2014-01-22 | 2014-01-23 | 118 | 25d | 0d |  | C | 16h | 1,680 |
| 120 | 1.1.2.2.11 | SRS freezed | 1d | 2014-01-24 | 2014-01-24 | 119 | 25d | 0d |  | B | 8h | 840 |
| 121 | 1.1.2.3 | **Design** | 25d | 2014-01-24 | 2014-02-27 |  | 26d |  |  |  | 488h | 51,240 |
| 122 | 1.1.2.3.1 | **High Level Design** | 13d | 2014-01-24 | 2014-02-11 |  | 25d | 0d |  |  | 128h | 13,440 |
| 123 | 1.1.2.3.1.1 | **Firmware** | 13d | 2014-01-24 | 2014-02-11 |  | 25d |  |  |  | 128h | 13,440 |
| 124 | 1.1.2.3.1.1.1 | **Team Meeting** | 2d | 2014-01-24 | 2014-01-27 |  | 26d |  |  |  | 16h | 1,680 |
| 125 | 1.1.2.3.1.1.1.1 | Discussion on HLD | 1d | 2014-01-24 | 2014-01-24 | 119 | 37d |  |  | C | 8h | 840 |
| 126 | 1.1.2.3.1.1.1.2 | Introduction and General description | 1d | 2014-01-27 | 2014-01-27 | 120 | 25d | 0d |  | A | 8h | 840 |
| 127 | 1.1.2.3.1.1.2 | Process Flow Diagram | 3d | 2014-01-28 | 2014-01-30 | 126 | 33d |  |  | A | 24h | 2,520 |
| 128 | 1.1.2.3.1.1.3 | Components and their Interfaces | 3d | 2014-01-28 | 2014-01-30 | 126 | 25d | 0d |  | B | 24h | 2,520 |
| 129 | 1.1.2.3.1.1.4 | Interactions between Components | 2d | 2014-01-31 | 2014-02-03 | 128 | 25d | 0d |  | B | 16h | 1,680 |
| 130 | 1.1.2.3.1.1.5 | Data Model of the Components and Interfaces | 2d | 2014-02-04 | 2014-02-05 | 129 | 25d | 0d |  | B | 16h | 1,680 |
| 131 | 1.1.2.3.1.1.6 | **Team Meeting** | 1d | 2014-02-06 | 2014-02-06 |  | 25d |  |  |  | 8h | 840 |
| 132 | 1.1.2.3.1.1.6.1 | Integration and Review of HLD | 1d | 2014-02-06 | 2014-02-06 | 130 | 25d | 0d |  | B | 8h | 840 |
| 133 | 1.1.2.3.1.1.7 | **Rework** | 3d | 2014-02-07 | 2014-02-11 |  | 25d |  |  |  | 24h | 2,520 |
| 134 | 1.1.2.3.1.1.7.1 | Discussion on review comments by customer | 1d | 2014-02-07 | 2014-02-07 | 132 | 25d | 0d |  | B | 8h | 840 |
| 135 | 1.1.2.3.1.1.7.2 | Rework as proposed by customer and freeze HLD | 2d | 2014-02-10 | 2014-02-11 | 134 | 25d | 0d |  | B | 16h | 1,680 |
| 136 | 1.1.2.3.2 | **Low Level Design** | 12d | 2014-02-12 | 2014-02-27 |  | 42d |  |  |  | 280h | 29,400 |
| 137 | 1.1.2.3.2.1 | **Firmware** | 12d | 2014-02-12 | 2014-02-27 |  | 42d |  |  |  | 280h | 29,400 |
| 138 | 1.1.2.3.2.1.1 | **Team meeting** | 1d | 2014-02-12 | 2014-02-12 |  | 42d |  |  |  | 8h | 840 |
| 139 | 1.1.2.3.2.1.1.1 | Discussion | 1d | 2014-02-12 | 2014-02-12 | 135 | 42d | 0d |  | A | 8h | 840 |
| 140 | 1.1.2.3.2.1.2 | Detail description of Architectural diagram | 3d | 2014-02-13 | 2014-02-17 | 139 | 50d |  |  | A | 24h | 2,520 |

| ID | WBS | Task | Duration | Start | Finish | Predecessors | Total slack | Free slack | Resources | Work | Cost |
| --- | --- | --- | --- | --- | --- | --- | --- | --- | --- | --- | --- |
| 141 | 1.1.2.3.2.1.3 | **Sensor Mdule** | 5d | 2014-02-13 | 2014-02-19 |  | 48d |  |  | 40h | 4,200 |
| 142 | 1.1.2.3.2.1.3.1 | Use case preparaiton | 3d | 2014-02-13 | 2014-02-17 | 139 | 48d | 0d | B | 24h | 2,520 |
| 143 | 1.1.2.3.2.1.3.2 | Define Functions and Data structures | 2d | 2014-02-18 | 2014-02-19 | 142 | 48d |  | B | 16h | 1,680 |
| 144 | 1.1.2.3.2.1.4 | **Configuration module** | 5d | 2014-02-13 | 2014-02-19 |  | 48d |  |  | 40h | 4,200 |
| 145 | 1.1.2.3.2.1.4.1 | Use case preparaiton | 3d | 2014-02-13 | 2014-02-17 | 139 | 48d | 0d | C | 24h | 2,520 |
| 146 | 1.1.2.3.2.1.4.2 | Define Functions and Data structures | 2d | 2014-02-18 | 2014-02-19 | 145 | 48d |  | C | 16h | 1,680 |
| 147 | 1.1.2.3.2.1.5 | **Mini Storage Module** | 5d | 2014-02-13 | 2014-02-19 |  | 48d |  |  | 40h | 4,200 |
| 148 | 1.1.2.3.2.1.5.1 | Use case preparaiton | 3d | 2014-02-13 | 2014-02-17 | 139 | 48d | 0d | D | 24h | 2,520 |
| 149 | 1.1.2.3.2.1.5.2 | Define Functions and Data structures | 2d | 2014-02-18 | 2014-02-19 | 148 | 48d |  | D | 16h | 1,680 |
| 150 | 1.1.2.3.2.1.6 | **Alert module** | 5d | 2014-02-13 | 2014-02-19 |  | 48d |  |  | 40h | 4,200 |
| 151 | 1.1.2.3.2.1.6.1 | Use case preparaiton | 3d | 2014-02-13 | 2014-02-17 | 139 | 48d | 0d | E | 24h | 2,520 |
| 152 | 1.1.2.3.2.1.6.2 | Define Functions and Data structures | 2d | 2014-02-18 | 2014-02-19 | 151 | 48d |  | E | 16h | 1,680 |
| 153 | 1.1.2.3.2.1.7 | **Interaction Module** | 5d | 2014-02-13 | 2014-02-19 |  | 42d |  |  | 40h | 4,200 |
| 154 | 1.1.2.3.2.1.7.1 | Use case preparaiton | 3d | 2014-02-13 | 2014-02-17 | 139 | 42d | 0d | F | 24h | 2,520 |
| 155 | 1.1.2.3.2.1.7.2 | Define Functions and Data structures | 2d | 2014-02-18 | 2014-02-19 | 154 | 42d | 0d | F | 16h | 1,680 |
| 156 | 1.1.2.3.2.1.8 | **Team Meeting** | 2d | 2014-02-20 | 2014-02-21 |  | 42d |  |  | 16h | 1,680 |
| 157 | 1.1.2.3.2.1.8.1 | Integration and Review of LLD | 2d | 2014-02-20 | 2014-02-21 | 155 | 42d | 0d | A | 16h | 1,680 |
| 158 | 1.1.2.3.2.1.9 | **Rework** | 4d | 2014-02-24 | 2014-02-27 |  | 42d |  |  | 32h | 3,360 |
| 159 | 1.1.2.3.2.1.9.1 | Discussion on review comments by customer | 1d | 2014-02-24 | 2014-02-24 | 157 | 42d | 0d | A | 8h | 840 |
| 160 | 1.1.2.3.2.1.9.2 | Rework as proposed by customer and freeze LLd | 3d | 2014-02-25 | 2014-02-27 | 159 | 42d |  | A | 24h | 2,520 |
| 161 | 1.1.2.3.3 | **Test Document Preparation** | 10d | 2014-01-27 | 2014-02-07 |  | 27d | 0d |  | 80h | 8,400 |
| 162 | 1.1.2.3.3.1 | Test Plan Preparation | 10d | 2014-01-27 | 2014-02-07 | 120 | 27d |  | C | 80h | 8,400 |
| 163 | 1.1.2.4 | **Pre Production** | 20d | 2014-01-24 | 2014-02-20 |  | 25d | 0d |  | 184h | 19,320 |
| 164 | 1.1.2.4.1 | Hardware Procurement | 9d | 2014-01-24 | 2014-02-05 | 112 | 36d |  | D | 72h | 7,560 |
| 165 | 1.1.2.4.2 | Assemble Development Team | 7d | 2014-02-12 | 2014-02-20 | 122 | 25d |  | H | 56h | 5,880 |
| 166 | 1.1.2.4.3 | Assemble Test Team | 7d | 2014-02-10 | 2014-02-18 | 161 | 27d |  | I | 56h | 5,880 |

| ID | WBS | Task | Duration | Start | Finish | Predecessors | Total slack | Free slack | Resources | Work | Cost |
| --- | --- | --- | --- | --- | --- | --- | --- | --- | --- | --- | --- |
| 167 | 1.1.2.5 | **Production/Implementation** | 12d | 2014-02-21 | 2014-03-10 |  | 25d | 0d |  | 376h | 39,480 |
| 168 | 1.1.2.5.1 | **Team Meeting** | 1d | 2014-02-21 | 2014-02-21 |  | 25d |  |  | 8h | 840 |
| 169 | 1.1.2.5.1.1 | Assign Task | 1d | 2014-02-21 | 2014-02-21 | 163 | 25d | 0d | B | 8h | 840 |
| 170 | 1.1.2.5.2 | **Sensor Module** | 7d | 2014-02-24 | 2014-03-04 |  | 29d |  |  | 64h | 6,720 |
| 171 | 1.1.2.5.2.1 | Coding | 5d | 2014-02-24 | 2014-02-28 | 169 | 29d | 0d | B | 40h | 4,200 |
| 172 | 1.1.2.5.2.2 | Code Review | 2d | 2014-03-03 | 2014-03-04 | 171 | 29d |  | A | 16h | 1,680 |
| 173 | 1.1.2.5.2.3 | Unit Testing | 1d | 2014-03-03 | 2014-03-03 | 171 | 30d |  | B | 8h | 840 |
| 174 | 1.1.2.5.3 | **Mini Storage Module** | 7d | 2014-02-24 | 2014-03-04 |  | 29d |  |  | 64h | 6,720 |
| 175 | 1.1.2.5.3.1 | Coding | 5d | 2014-02-24 | 2014-02-28 | 169 | 29d | 0d | C | 40h | 4,200 |
| 176 | 1.1.2.5.3.2 | Code Review | 2d | 2014-03-03 | 2014-03-04 | 175 | 29d |  | D | 16h | 1,680 |
| 177 | 1.1.2.5.3.3 | Unit Testing | 1d | 2014-03-03 | 2014-03-03 | 175 | 30d |  | C | 8h | 840 |
| 178 | 1.1.2.5.4 | **Configuration Module** | 7d | 2014-02-24 | 2014-03-04 |  | 29d |  |  | 64h | 6,720 |
| 179 | 1.1.2.5.4.1 | Coding | 5d | 2014-02-24 | 2014-02-28 | 169 | 29d | 0d | D | 40h | 4,200 |
| 180 | 1.1.2.5.4.2 | Code Review | 2d | 2014-03-03 | 2014-03-04 | 179 | 29d |  | F | 16h | 1,680 |
| 181 | 1.1.2.5.4.3 | Unit Testing | 1d | 2014-03-03 | 2014-03-03 | 179 | 30d |  | E | 8h | 840 |
| 182 | 1.1.2.5.5 | **Alert Module** | 7d | 2014-02-24 | 2014-03-04 |  | 29d |  |  | 64h | 6,720 |
| 183 | 1.1.2.5.5.1 | Coding | 5d | 2014-02-24 | 2014-02-28 | 169 | 29d | 0d | E | 40h | 4,200 |
| 184 | 1.1.2.5.5.2 | Code Review | 2d | 2014-03-03 | 2014-03-04 | 183 | 29d |  | H | 16h | 1,680 |
| 185 | 1.1.2.5.5.3 | Unit Testing | 1d | 2014-03-03 | 2014-03-03 | 183 | 30d |  | I | 8h | 840 |
| 186 | 1.1.2.5.6 | **Interaction Module** | 7d | 2014-02-24 | 2014-03-04 |  | 25d | 0d |  | 64h | 6,720 |
| 187 | 1.1.2.5.6.1 | Coding | 5d | 2014-02-24 | 2014-02-28 | 169 | 25d | 0d | F | 40h | 4,200 |
| 188 | 1.1.2.5.6.2 | Code Review | 2d | 2014-03-03 | 2014-03-04 | 187 | 25d |  | K | 16h | 1,680 |
| 189 | 1.1.2.5.6.3 | Unit Testing | 1d | 2014-03-03 | 2014-03-03 | 187 | 26d |  | J | 8h | 840 |
| 190 | 1.1.2.5.7 | **Integration** | 4d | 2014-03-05 | 2014-03-10 |  | 25d |  |  | 48h | 5,040 |
| 191 | 1.1.2.5.7.1 | Integration of modules | 2d | 2014-03-05 | 2014-03-06 | 186 | 25d | 0d | A | 16h | 1,680 |
| 192 | 1.1.2.5.7.2 | Tool run for static code analysis and fixing | 2d | 2014-03-07 | 2014-03-10 | 191 | 25d |  | B | 16h | 1,680 |
| 193 | 1.1.2.5.7.3 | Integration Testing | 2d | 2014-03-07 | 2014-03-10 | 191 | 25d |  | C | 16h | 1,680 |

| ID | WBS | Task | Duration | Start | Finish | Predecessors | Total slack | Free slack | Constraint | Resources | Work | Cost |
| --- | --- | --- | --- | --- | --- | --- | --- | --- | --- | --- | --- | --- |
| 194 | 1.1.2.6 | **Production/Testing** | 11d | 2014-03-11 | 2014-03-25 |  | 19d | 0d |  |  | 96h | 10,080 |
| 195 | 1.1.2.6.1 | Testing by test team | 5d | 2014-03-11 | 2014-03-17 | 167 | 25d |  |  | A | 40h | 4,200 |
| 196 | 1.1.2.6.2 | Bug fixing | 5d | 2014-03-17 | 2014-03-21 |  | 19d | 0d | start no earlier than 2014-03-17 | B | 40h | 4,200 |
| 197 | 1.1.2.6.3 | Re-Testing of Bugs fixed | 2d | 2014-03-24 | 2014-03-25 | 196 | 19d |  |  | A | 16h | 1,680 |
| 198 | 1.1.2.7 | **Release** | 5d | 2014-03-26 | 2014-04-01 |  | 19d |  |  |  | 120h | 12,600 |
| 199 | 1.1.2.7.1 | Release Document Preparation | 5d | 2014-03-26 | 2014-04-01 | 194 | 19d |  |  | A | 40h | 4,200 |
| 200 | 1.1.2.7.2 | User Manual Preparation | 5d | 2014-03-26 | 2014-04-01 | 194 | 19d |  |  | B | 40h | 4,200 |
| 201 | 1.1.2.7.3 | Trouble Shooting Guide | 5d | 2014-03-26 | 2014-04-01 | 194 | 19d |  |  | C | 40h | 4,200 |
| 202 | 1.2 | **Composite Testing** | 18d | 2014-04-29 | 2014-05-22 | 2 | 0d |  |  | DDT | 208h | 117,600 |
| 203 | 1.2.1 | **First Round Testing** | 18d | 2014-04-29 | 2014-05-22 |  | 0d |  |  |  | 40h | 16,800 |
| 204 | 1.2.1.1 | **Initial testing** | 10d | 2014-04-29 | 2014-05-12 |  | 0d |  |  |  | 40h | 16,800 |
| 205 | 1.2.1.1.1 | Regression Tests | 5d | 2014-04-29 | 2014-05-05 |  | 0d |  |  |  |  |  |
| 206 | 1.2.1.1.2 | User Tests | 5d | 2014-05-06 | 2014-05-12 | 205 | 0d |  |  | QA | 40h | 16,800 |
| 207 | 1.2.1.2 | Analysis of test results | 3d | 2014-05-13 | 2014-05-15 | 204 | 0d |  |  |  |  |  |
| 208 | 1.2.1.3 | Implement Design Changes | 5d | 2014-05-16 | 2014-05-22 | 207 | 0d |  |  |  |  |  |
| 209 | 1.2.2 | **Second Round Testing** | 3d | 2014-04-29 | 2014-05-01 |  | 15d |  |  |  | 24h | 10,080 |
| 210 | 1.2.2.1 | **Initial testing** | 3d | 2014-04-29 | 2014-05-01 |  | 15d |  |  |  | 24h | 10,080 |
| 211 | 1.2.2.1.1 | Regression Tests | 3d | 2014-04-29 | 2014-05-01 |  | 15d |  |  |  |  |  |
| 212 | 1.2.2.1.2 | User Tests | 3d | 2014-04-29 | 2014-05-01 |  | 15d |  |  | QA | 24h | 10,080 |
| 213 | 1.2.2.2 | Analysis of test results | 2d | 2014-04-29 | 2014-04-30 |  | 16d |  |  |  |  |  |
| 214 | 1.2.2.3 | Implement Design Changes | 3d | 2014-04-29 | 2014-05-01 |  | 15d |  |  |  |  |  |
